# GSTOP

Schedule from MS Project, 2004-10-01 to 2006-05-25.

## Calendars

- Standard: Mon-Fri 08:00-12:00, 13:00-17:00; Sat-Sun off.

## Resources

| Resource |
| --- |
| Sgoodman |
| Smclellan |
| Jfrost |
| GTG |
| GTG Exec Comm |
| Karen Folger |
| Ken Bottle |
| Emmor Nile |
| Victoria Smith |
| Ed Delaney |
| Miranda Miller |

## Schedule

| ID | WBS | Task | Type | Duration | Start | Finish | Predecessors | Baseline start | Baseline finish | Baseline duration | Total slack | Free slack | Constraint | Resources | Work |
| --- | --- | --- | --- | --- | --- | --- | --- | --- | --- | --- | --- | --- | --- | --- | --- |
| 1 | 1 | GSTOP PROJECT |  | 430d | 2004-10-01 | 2006-05-25 |  | 2004-10-01 | 2006-05-25 | 430d | 0d |  | start no earlier than 2004-10-01 |  |  |
| 2 | 2 | **GSTOP Project Initiation** |  | 96d? | 2004-10-12 | 2005-02-22 |  | 2004-10-12 | 2005-01-14 | 69d? | 327d |  |  | Sgoodman | 2304h |
| 3 | 2.1 | **Initiate the GSTOP Project** |  | 39d | 2004-10-12 | 2004-12-03 |  | 2004-10-12 | 2004-12-15 | 47d | 384d |  |  |  |  |
| 4 | 2.1.1 | GSTOP Executive Committee Formed |  | 4d | 2004-11-30 | 2004-12-03 |  | 2004-11-01 | 2004-11-04 | 4d | 384d |  | finish no earlier than 2004-12-03 |  |  |
| 5 | 2.1.2 | GSTOP Project Manager Identified |  | 2d | 2004-11-30 | 2004-12-01 |  | 2004-11-30 | 2004-12-01 | 2d | 386d |  | finish no earlier than 2004-12-01 |  |  |
| 6 | 2.1.3 | GSTOP Project Charter Approved |  | 7d | 2004-10-12 | 2004-10-20 |  | 2004-10-12 | 2004-10-20 | 7d | 416d |  | finish no earlier than 2004-10-20 |  |  |
| 7 | 2.1.4 | GSTOP Project Funding Secured |  | 4d | 2004-10-15 | 2004-10-20 |  | 2004-10-15 | 2004-10-20 | 4d | 416d |  | finish no earlier than 2004-10-20 |  |  |
| 8 | 2.1.5 | GSTOP Project Team Identified |  | 4d | 2004-11-30 | 2004-12-03 |  | 2004-12-10 | 2004-12-15 | 4d | 384d |  | start no earlier than 2004-11-30 |  |  |
| 9 | 2.2 | **Form the GSTOP Team** |  | 29d? | 2004-12-01 | 2005-01-10 |  | 2004-12-01 | 2005-01-10 | 29d? | 358d |  |  |  | 176h |
| 10 | 2.2.1 | Research IQS and ROSS for potential Busns Lead candidates |  | 11d? | 2004-12-01 | 2004-12-15 |  | 2004-12-01 | 2004-12-15 | 11d? | 365.5d | 7.5d | finish no earlier than 2004-12-15 | Sgoodman | 88h |
| 11 | 2.2.2 | Contact potential Bus Lead candidates |  | 0.5d? | 2004-12-27 | 2004-12-27 | 10 | 2004-12-27 | 2004-12-27 | 0.5d? | 358d | 0d | finish no earlier than 2004-12-27 | Smclellan; Jfrost | 8h |
| 12 | 2.2.3 | Identify GSTOP Project Business Lead |  | 10d | 2004-12-28 | 2005-01-10 | 11 | 2004-12-28 | 2005-01-10 | 10d | 358d |  | finish no earlier than 2004-12-29 | GTG Exec Comm | 80h |
| 13 | 2.2.4 | Develop Project Team Operating Principles & Guidelines | milestone | 0d | 2004-12-01 | 2004-12-01 |  | 2004-12-01 | 2004-12-01 | 1d? | 387d |  |  |  |  |
| 14 | 2.3 | **Develop the GSTOP Project Management Plans** |  | 60d? | 2004-12-01 | 2005-02-22 |  | 2004-12-01 | 2005-01-14 | 33d? | 327d |  |  |  | 1360h |
| 15 | 2.3.1 | Review Charter and resolve any ambiguities/issues |  | 1d? | 2004-12-01 | 2004-12-01 |  | 2004-12-01 | 2004-12-01 | 1d? | 386d |  |  |  |  |
| 16 | 2.3.2 | **Workbreak Down Structure** |  | 33d | 2004-12-01 | 2005-01-14 |  | 2004-12-01 | 2005-01-14 | 33d | 354d |  |  |  | 384h |
| 17 | 2.3.2.1 | WBS Structure Symbology |  | 8d | 2005-01-05 | 2005-01-14 |  | 2005-01-05 | 2005-01-14 | 8d | 354d |  | finish no earlier than 2005-01-14 | Ken Bottle | 64h |
| 18 | 2.3.2.2 | Standard Map Product Definition |  | 8d | 2005-01-05 | 2005-01-14 |  | 2005-01-05 | 2005-01-14 | 8d | 354d |  | finish no earlier than 2005-01-14 | Karen Folger | 64h |
| 19 | 2.3.2.3 | Naming Conventions |  | 8d | 2005-01-05 | 2005-01-14 |  | 2005-01-05 | 2005-01-14 | 8d | 354d |  | finish no earlier than 2005-01-14 | Emmor Nile | 64h |
| 20 | 2.3.2.4 | GIST Minimum Expectations |  | 8d | 2005-01-05 | 2005-01-14 |  | 2005-01-05 | 2005-01-14 | 8d | 354d |  | finish no earlier than 2005-01-14 | Victoria Smith | 64h |
| 21 | 2.3.2.5 | Data Sharing and Archiving |  | 8d | 2005-01-05 | 2005-01-14 |  | 2005-01-05 | 2005-01-14 | 8d | 354d |  | finish no earlier than 2005-01-14 | Ed Delaney | 64h |
| 22 | 2.3.2.6 | Minimum Essential Datasets |  | 8d | 2004-12-01 | 2004-12-10 |  | 2004-12-01 | 2004-12-10 | 8d | 379d |  |  | Miranda Miller | 64h |
| 23 | 2.3.3 | Develop Project Work Plan |  | 60d | 2004-12-01 | 2005-02-22 |  | 2004-12-01 | 2004-12-01 | 1d? | 327d | 0d |  | Smclellan | 480h |
| 24 | 2.3.4 | Workplan Submitted to Executive Committee | milestone | 0d | 2005-02-22 | 2005-02-22 | 23 |  |  |  | 327d |  | finish no earlier than 2005-01-31 | Smclellan |  |
| 25 | 2.3.5 | Develop Project Communication Plan |  | 44d | 2004-12-01 | 2005-01-31 |  | 2004-12-06 | 2004-12-06 | 1d | 343d |  | finish no earlier than 2005-01-31 | Smclellan | 352h |
| 26 | 2.3.6 | Develop Project Responsibility Matrix |  | 9d? | 2005-01-19 | 2005-01-31 |  | 2004-12-01 | 2004-12-01 | 1d? | 343d |  | finish no earlier than 2005-01-31 | Smclellan | 72h |
| 27 | 2.3.7 | Develop Project Resource Plan |  | 9d? | 2005-01-19 | 2005-01-31 |  | 2004-12-01 | 2004-12-01 | 1d? | 343d |  | finish no earlier than 2005-01-31 | Smclellan | 72h |

| ID | WBS | Task | Duration | Start | Finish | Predecessors | Baseline start | Baseline finish | Baseline duration | Total slack | Free slack |
| --- | --- | --- | --- | --- | --- | --- | --- | --- | --- | --- | --- |
| 28 | 2.4 | **Develop the GSTOP Communication and Management Structures** | 1d? | 2004-12-01 | 2004-12-01 |  | 2004-12-01 | 2004-12-01 | 1d? | 386d |  |
| 29 | 2.4.1 | Research 4 websites and select option for public communications | 1d? | 2004-12-01 | 2004-12-01 |  | 2004-12-01 | 2004-12-01 | 1d? | 386d |  |
| 30 | 2.4.2 | Create GSTOP private team workspace | 1d? | 2004-12-01 | 2004-12-01 |  | 2004-12-01 | 2004-12-01 | 1d? | 386d |  |
| 31 | 2.4.3 | Develop Project Status Report Template | 1d? | 2004-12-01 | 2004-12-01 |  | 2004-12-01 | 2004-12-01 | 1d? | 386d |  |
| 33 | 3 | **GSTOP Business Requirements** | 5d? | 2004-12-01 | 2004-12-07 |  | 2004-12-01 | 2004-12-07 | 5d? | 378d | 0d |
| 34 | 3.1 | Define and Assign Project Subteams | 1d? | 2004-12-01 | 2004-12-01 |  | 2004-12-01 | 2004-12-01 | 1d? | 382d |  |
| 35 | 3.2 | **Incident GIS Standard Symbology Requirements** | 5d? | 2004-12-01 | 2004-12-07 |  | 2004-12-01 | 2004-12-07 | 5d? | 378d |  |
| 36 | 3.2.1 | Define Information Needs (What do we need to gather?) | 1d? | 2004-12-01 | 2004-12-01 |  | 2004-12-01 | 2004-12-01 | 1d? | 378d | 0d |
| 37 | 3.2.2 | Perform Information Collection | 1d? | 2004-12-02 | 2004-12-02 | 36 | 2004-12-02 | 2004-12-02 | 1d? | 378d | 0d |
| 38 | 3.2.3 | Conduct Analysis | 1d? | 2004-12-03 | 2004-12-03 | 37 | 2004-12-03 | 2004-12-03 | 1d? | 378d | 0d |
| 39 | 3.2.4 | Develop Preliminary Requirements Specifications | 1d? | 2004-12-06 | 2004-12-06 | 38 | 2004-12-06 | 2004-12-06 | 1d? | 378d | 0d |
| 40 | 3.2.5 | Requirements Review and Validation | 1d? | 2004-12-07 | 2004-12-07 | 39 | 2004-12-07 | 2004-12-07 | 1d? | 378d |  |
| 41 | 3.3 | **Incident GIS Standard Naming Conventions Requirements** | 5d? | 2004-12-01 | 2004-12-07 |  | 2004-12-01 | 2004-12-07 | 5d? | 378d |  |
| 42 | 3.3.1 | Define Information Needs (What do we need to gather?) | 1d? | 2004-12-01 | 2004-12-01 |  | 2004-12-01 | 2004-12-01 | 1d? | 378d | 0d |
| 43 | 3.3.2 | Perform Information Collection | 1d? | 2004-12-02 | 2004-12-02 | 42 | 2004-12-02 | 2004-12-02 | 1d? | 378d | 0d |
| 44 | 3.3.3 | Conduct Analysis | 1d? | 2004-12-03 | 2004-12-03 | 43 | 2004-12-03 | 2004-12-03 | 1d? | 378d | 0d |
| 45 | 3.3.4 | Develop Preliminary Requirements Specifications | 1d? | 2004-12-06 | 2004-12-06 | 44 | 2004-12-06 | 2004-12-06 | 1d? | 378d | 0d |
| 46 | 3.3.5 | Requirements Review and Validation | 1d? | 2004-12-07 | 2004-12-07 | 45 | 2004-12-07 | 2004-12-07 | 1d? | 378d |  |
| 47 | 3.4 | **Incident GIS Standard Product Definitions Requirements** | 5d? | 2004-12-01 | 2004-12-07 |  | 2004-12-01 | 2004-12-07 | 5d? | 378d |  |
| 48 | 3.4.1 | Define Information Needs (What do we need to gather?) | 1d? | 2004-12-01 | 2004-12-01 |  | 2004-12-01 | 2004-12-01 | 1d? | 378d | 0d |
| 49 | 3.4.2 | Perform Information Collection | 1d? | 2004-12-02 | 2004-12-02 | 48 | 2004-12-02 | 2004-12-02 | 1d? | 378d | 0d |
| 50 | 3.4.3 | Conduct Analysis | 1d? | 2004-12-03 | 2004-12-03 | 49 | 2004-12-03 | 2004-12-03 | 1d? | 378d | 0d |
| 51 | 3.4.4 | Develop Preliminary Requirements Specifications | 1d? | 2004-12-06 | 2004-12-06 | 50 | 2004-12-06 | 2004-12-06 | 1d? | 378d | 0d |
| 52 | 3.4.5 | Requirements Review and Validation | 1d? | 2004-12-07 | 2004-12-07 | 51 | 2004-12-07 | 2004-12-07 | 1d? | 378d |  |

| ID | WBS | Task | Duration | Start | Finish | Predecessors | Baseline start | Baseline finish | Baseline duration | Total slack | Free slack |
| --- | --- | --- | --- | --- | --- | --- | --- | --- | --- | --- | --- |
| 53 | 3.5 | **Incident GIST Minimum Qualifications Requirements** | 5d? | 2004-12-01 | 2004-12-07 |  | 2004-12-01 | 2004-12-07 | 5d? | 378d |  |
| 54 | 3.5.1 | Define Information Needs (What do we need to gather?) | 1d? | 2004-12-01 | 2004-12-01 |  | 2004-12-01 | 2004-12-01 | 1d? | 378d | 0d |
| 55 | 3.5.2 | Perform Information Collection | 1d? | 2004-12-02 | 2004-12-02 | 54 | 2004-12-02 | 2004-12-02 | 1d? | 378d | 0d |
| 56 | 3.5.3 | Conduct Analysis | 1d? | 2004-12-03 | 2004-12-03 | 55 | 2004-12-03 | 2004-12-03 | 1d? | 378d | 0d |
| 57 | 3.5.4 | Develop Preliminary Requirements Specifications | 1d? | 2004-12-06 | 2004-12-06 | 56 | 2004-12-06 | 2004-12-06 | 1d? | 378d | 0d |
| 58 | 3.5.5 | Requirements Review and Validation | 1d? | 2004-12-07 | 2004-12-07 | 57 | 2004-12-07 | 2004-12-07 | 1d? | 378d |  |
| 59 | 3.6 | **Incident GIS Minimum Essential Datasets Requirements** | 5d? | 2004-12-01 | 2004-12-07 |  | 2004-12-01 | 2004-12-07 | 5d? | 378d |  |
| 60 | 3.6.1 | Define Information Needs (What do we need to gather?) | 1d? | 2004-12-01 | 2004-12-01 |  | 2004-12-01 | 2004-12-01 | 1d? | 378d | 0d |
| 61 | 3.6.2 | Perform Information Collection | 1d? | 2004-12-02 | 2004-12-02 | 60 | 2004-12-02 | 2004-12-02 | 1d? | 378d | 0d |
| 62 | 3.6.3 | Conduct Analysis | 1d? | 2004-12-03 | 2004-12-03 | 61 | 2004-12-03 | 2004-12-03 | 1d? | 378d | 0d |
| 63 | 3.6.4 | Develop Preliminary Requirements Specifications | 1d? | 2004-12-06 | 2004-12-06 | 62 | 2004-12-06 | 2004-12-06 | 1d? | 378d | 0d |
| 64 | 3.6.5 | Requirements Review and Validation | 1d? | 2004-12-07 | 2004-12-07 | 63 | 2004-12-07 | 2004-12-07 | 1d? | 378d |  |
| 65 | 3.7 | **Incident GIS Standard Data Sharing, Archiving, Documentation and Transition Requirements** | 5d? | 2004-12-01 | 2004-12-07 |  | 2004-12-01 | 2004-12-07 | 5d? | 378d |  |
| 66 | 3.7.1 | Define Information Needs (What do we need to gather?) | 1d? | 2004-12-01 | 2004-12-01 |  | 2004-12-01 | 2004-12-01 | 1d? | 378d | 0d |
| 67 | 3.7.2 | Perform Information Collection | 1d? | 2004-12-02 | 2004-12-02 | 66 | 2004-12-02 | 2004-12-02 | 1d? | 378d | 0d |
| 68 | 3.7.3 | Conduct Analysis | 1d? | 2004-12-03 | 2004-12-03 | 67 | 2004-12-03 | 2004-12-03 | 1d? | 378d | 0d |
| 69 | 3.7.4 | Develop Preliminary Requirements Specifications | 1d? | 2004-12-06 | 2004-12-06 | 68 | 2004-12-06 | 2004-12-06 | 1d? | 378d | 0d |
| 70 | 3.7.5 | Requirements Review and Validation | 1d? | 2004-12-07 | 2004-12-07 | 69 | 2004-12-07 | 2004-12-07 | 1d? | 378d |  |
| 71 | 3.8 | Consolidate Incident GIS SOP Requirements | 1d? | 2004-12-01 | 2004-12-01 |  | 2004-12-01 | 2004-12-01 | 1d? | 382d |  |
| 72 | 3.9 | Review all Incident GIS SOP Requirements together | 1d? | 2004-12-01 | 2004-12-01 |  | 2004-12-01 | 2004-12-01 | 1d? | 382d |  |
| 73 | 3.10 | Incorporate Feedback and Revise Incident GIS SOP Requirements as needed | 1d? | 2004-12-01 | 2004-12-01 |  | 2004-12-01 | 2004-12-01 | 1d? | 382d |  |
| 74 | 3.11 | Final Business Requirements Completed (Milestone) | 1d? | 2004-12-01 | 2004-12-01 |  | 2004-12-01 | 2004-12-01 | 1d? | 382d |  |
| 76 | 4 | **Draft Incident GIS SOPs** | 1d? | 2004-12-08 | 2004-12-08 | 33 | 2004-12-08 | 2004-12-08 | 1d? | 378d | 0d |
| 77 | 4.1 | Define Information Needs (What do we need to gather?) | 1d? | 2004-12-08 | 2004-12-08 |  | 2004-12-08 | 2004-12-08 | 1d? | 378d |  |
| 78 | 4.2 | Perform Information Collection | 1d? | 2004-12-08 | 2004-12-08 |  | 2004-12-08 | 2004-12-08 | 1d? | 378d |  |
| 79 | 4.3 | Conduct Analysis | 1d? | 2004-12-08 | 2004-12-08 |  | 2004-12-08 | 2004-12-08 | 1d? | 378d |  |
| 80 | 4.4 | Develop Preliminary SOP’s | 1d? | 2004-12-08 | 2004-12-08 |  | 2004-12-08 | 2004-12-08 | 1d? | 378d |  |
| 81 | 4.5 | Review and Validation of SOP’s | 1d? | 2004-12-08 | 2004-12-08 |  | 2004-12-08 | 2004-12-08 | 1d? | 378d |  |
| 82 | 4.6 | Incorporate Feedback | 1d? | 2004-12-08 | 2004-12-08 |  | 2004-12-08 | 2004-12-08 | 1d? | 378d |  |
| 83 | 4.7 | GSTOP Change Management Plan Development | 1d? | 2004-12-08 | 2004-12-08 |  | 2004-12-08 | 2004-12-08 | 1d? | 378d |  |
| 84 | 4.8 | GSTOP Change Management Plan Review by Executive Committee | 1d? | 2004-12-08 | 2004-12-08 |  | 2004-12-08 | 2004-12-08 | 1d? | 378d |  |
| 85 | 4.9 | Preliminary SOP’s Ready for Field Testing (Milestone) | 1d? | 2004-12-08 | 2004-12-08 |  | 2004-12-08 | 2004-12-08 | 1d? | 378d |  |

| ID | WBS | Task | Type | Duration | Start | Finish | Predecessors | Baseline start | Baseline finish | Baseline duration | Total slack | Free slack |
| --- | --- | --- | --- | --- | --- | --- | --- | --- | --- | --- | --- | --- |
| 87 | 5 | **Incident GIS SOPs Field Test** |  | 1d? | 2004-12-09 | 2004-12-09 | 76 | 2004-12-09 | 2004-12-09 | 1d? | 378d | 0d |
| 88 | 5.1 | Develop Quality Assurance and Field Test Plan |  | 1d? | 2004-12-09 | 2004-12-09 |  | 2004-12-09 | 2004-12-09 | 1d? | 378d |  |
| 89 | 5.2 | Execute Quality Assurance and Field Test Plan |  | 1d? | 2004-12-09 | 2004-12-09 |  | 2004-12-09 | 2004-12-09 | 1d? | 378d |  |
| 90 | 5.3 | Analyze Quality Assurance and Field Test Plan Results |  | 1d? | 2004-12-09 | 2004-12-09 |  | 2004-12-09 | 2004-12-09 | 1d? | 378d |  |
| 92 | 6 | **Final Incident GIS SOPs** |  | 1d? | 2004-12-09 | 2004-12-10 | 87 | 2004-12-09 | 2004-12-10 | 1d? | 378d | 0d |
| 93 | 6.1 | Analyze feedback on Incident GIS SOPs |  | 1d? | 2004-12-10 | 2004-12-10 |  | 2004-12-10 | 2004-12-10 | 1d? | 378d |  |
| 94 | 6.2 | Update and finalize Incident GIS SOPs |  | 1d? | 2004-12-10 | 2004-12-10 |  | 2004-12-10 | 2004-12-10 | 1d? | 378d |  |
| 95 | 6.3 | Deliver Final Incident GIS SOPs to Executive Committee | milestone | 0d | 2004-12-09 | 2004-12-09 |  | 2004-12-09 | 2004-12-09 | 0d | 379d |  |
| 96 | 6.4 | Deliver Final Incident GIS SOPs to Incident Based Automation Project | milestone | 0d | 2004-12-09 | 2004-12-09 |  | 2004-12-09 | 2004-12-09 | 0d | 379d |  |
| 98 | 7 | **GSTOP Project Closeout** |  | 1d? | 2004-12-10 | 2004-12-13 | 92 | 2004-12-10 | 2004-12-13 | 1d? | 378d |  |
| 99 | 7.1 | Prepare GSTOP Team Recommendations for Future |  | 1d? | 2004-12-13 | 2004-12-13 |  | 2004-12-13 | 2004-12-13 | 1d? | 378d |  |
| 100 | 7.2 | Document Lessons Learned |  | 1d? | 2004-12-13 | 2004-12-13 |  | 2004-12-13 | 2004-12-13 | 1d? | 378d |  |
| 101 | 7.3 | GSTOP Project Team released | milestone | 0d | 2004-12-10 | 2004-12-10 |  | 2004-12-10 | 2004-12-10 | 0d | 379d |  |
